# Solaris->Linux Flight Plan

Schedule from MS Project, 2023-09-01 to 2025-08-01.

## Calendars

- Standard: Mon-Fri 08:00-12:00, 13:00-17:00; Sat-Sun off.

## Schedule

| ID | WBS | Task | Type | Duration | Start | Finish | Predecessors | Total slack | Free slack | Constraint |
| --- | --- | --- | --- | --- | --- | --- | --- | --- | --- | --- |
| 1 | 1 | **SPSS** |  | 434d? | 2023-09-01 | 2025-04-30 |  | 67d |  |  |
| 2 | 1.1 | SPSS Development Linux VMs Setup |  | 196d? | 2023-09-01 | 2024-05-31 |  | 175d | 0d | finish no earlier than 2024-05-31 |
| 3 | 1.2 | SPSS Testing |  | 22d? | 2024-06-03 | 2024-07-02 | 2 | 240d | 173d | start no earlier than 2023-10-02 |
| 4 | 1.3 | SPSS Parallel Operations |  | 43d? | 2025-03-03 | 2025-04-30 | 3 | 67d | 0d | finish no earlier than 2025-04-30 |
| 5 | 1.4 | SPSS off of Solaris | milestone | 0d | 2025-04-30 | 2025-04-30 | 4 | 67d |  | start no earlier than 2024-05-10 |
| 6 | 2 | **PASS** |  | 458d? | 2023-09-01 | 2025-06-03 |  | 0d |  |  |
| 7 | 2.1 | PASS Development |  | 371d? | 2023-09-01 | 2025-01-31 |  | 0d |  | finish no earlier than 2025-01-31 |
| 8 | 2.2 | PASS Development of PDBMon Complete (TBR) |  | 21d? | 2024-02-01 | 2024-02-29 |  | 371d |  | finish no earlier than 2024-02-29 |
| 9 | 2.3 | PASS Testing |  | 44d? | 2025-02-03 | 2025-04-03 | 7 | 43d | 0d | start no earlier than 2024-09-02 |
| 10 | 2.4 | PASS Parallel Operations |  | 43d? | 2025-04-04 | 2025-06-03 | 9 | 43d | 0d | finish no earlier than 2025-04-30 |
| 11 | 2.5 | PASS off of Solaris | milestone | 0d | 2025-06-03 | 2025-06-03 | 10 | 43d |  |  |
| 12 | 3 | **SMSB** |  | 130d? | 2025-02-03 | 2025-08-01 |  | 0d |  |  |
| 13 | 3.1 | SMSB Tools Development |  | 65d? | 2025-02-03 | 2025-05-02 | 2, 7, 32 | 0d |  | finish no earlier than 2024-11-29 |
| 14 | 3.2 | SMSB Tools Testing |  | 65d? | 2025-05-05 | 2025-08-01 | 13 | 0d |  | start no earlier than 2024-12-02 |
| 15 | 3.3 | SMSB off of Solaris | milestone | 0d | 2025-08-01 | 2025-08-01 | 14 | 0d |  |  |
| 16 | 4 | **Commanding** |  | 348d? | 2023-09-01 | 2024-12-31 |  | 153d |  |  |
| 17 | 4.1 | Commanding Development Linux VMs Setup |  | 21d? | 2023-09-01 | 2023-09-29 |  | 262d | 0d | finish no earlier than 2023-09-29 |
| 18 | 4.2 | Commanding Development |  | 109d? | 2023-10-02 | 2024-02-29 | 17 | 262d | 109d | start no earlier than 2023-10-02 |
| 19 | 4.3 | Commanding Testing |  | 109d? | 2024-08-01 | 2024-12-31 | 18 | 153d | 0d | finish no earlier than 2024-12-31 |
| 20 | 4.4 | Commanding off of Solaris | milestone | 0d | 2024-12-31 | 2024-12-31 | 19 | 153d |  |  |
| 21 | 5 | **PRD** |  | 218d? | 2023-10-02 | 2024-07-31 |  | 262d |  |  |
| 22 | 5.1 | PRD Development Linux VMs Setup |  | 22d? | 2023-10-02 | 2023-10-31 |  | 262d | 0d | finish no earlier than 2023-10-31 |
| 23 | 5.2 | PRD Development |  | 66d? | 2023-11-01 | 2024-01-31 | 22 | 262d | 0d | start no earlier than 2023-11-01 |
| 24 | 5.3 | PRD Testing |  | 130d? | 2024-02-01 | 2024-07-31 | 23 | 262d | 0d | start no earlier than 2024-02-01 |
| 25 | 5.4 | PRD off of Solaris | milestone | 0d | 2024-07-31 | 2024-07-31 | 24 | 262d |  |  |

| ID | WBS | Task | Type | Duration | Start | Finish | Predecessors | Total slack | Free slack | Constraint |
| --- | --- | --- | --- | --- | --- | --- | --- | --- | --- | --- |
| 27 | 6 | **OPB** |  | 21d? | 2025-03-03 | 2025-03-31 |  | 89d |  |  |
| 28 | 6.1 | OPB Tools Development & Testing |  | 21d? | 2025-03-03 | 2025-03-31 | 2, 32 | 89d | 0d | finish no earlier than 2025-03-31 |
| 29 | 6.2 | OPB off of Solaris | milestone | 0d | 2025-03-31 | 2025-03-31 | 28 | 89d |  |  |
| 30 | 7 | **SOGS** |  | 152d? | 2023-10-02 | 2024-04-30 |  | 198d |  |  |
| 31 | 7.1 | SOGS Linux Version Upgrade |  | 152d? | 2023-10-02 | 2024-04-30 |  | 198d | 0d | finish no earlier than 2024-04-30 |
| 32 | 7.2 | SOGS at REL 9 | milestone | 0d | 2024-04-30 | 2024-04-30 | 31 | 198d |  |  |
| 33 | 8 | **OBS** |  | 65d? | 2023-12-01 | 2024-02-29 |  | 371d |  |  |
| 34 | 8.1 | OBS Linux Hardware Install |  | 65d? | 2023-12-01 | 2024-02-29 |  | 371d | 0d | finish no earlier than 2024-02-29 |
| 35 | 8.2 | OBS Linux Hardware Ready | milestone | 0d | 2024-02-29 | 2024-02-29 | 34 | 371d |  |  |
| 36 | 9 | **ITSD** |  | 1d? | 2024-04-02 | 2024-04-02 |  | 348d |  |  |
| 37 | 9.1 | Task 1 - Working VM |  | 1d? | 2024-04-02 | 2024-04-02 |  | 348d |  |  |
| 38 | 10 | **OPGS** |  | 150d | 2024-05-27 | 2024-12-20 |  | 160d |  |  |
| 39 | 10.1 | Re-write SpecCom tool for SOGS linux environment |  | 90d | 2024-05-27 | 2024-09-27 |  | 185d | 10d | finish no earlier than 2024-09-27 |
| 40 | 10.2 | Test SpecCom Tool |  | 30d | 2024-10-14 | 2024-11-22 | 39 | 175d | 15d | finish no earlier than 2024-11-22 |
| 41 | 10.3 | Release SpecCom Tool to Operations |  | 5d | 2024-12-16 | 2024-12-20 | 40 | 160d | 0d | finish no earlier than 2024-12-20 |
| 42 | 10.4 | SpecCom in Ops | milestone | 0d | 2024-12-20 | 2024-12-20 | 41 | 160d |  |  |
